# LCGT_AOS_20111124

Schedule from MS Project, 2011-11-24 to 2015-03-31.

## Calendars

- 標準: Mon-Fri 08:00-12:00, 13:00-17:00; Sat-Sun off.

## Resources

| Resource |
| --- |
| aiueo |

## Schedule

| ID | WBS | Task | Type | Duration | Start | Finish | Predecessors | Total slack | Constraint |
| --- | --- | --- | --- | --- | --- | --- | --- | --- | --- |
| 1 | 1 | 前提0: とりあえずiLCGTだけをつくることを考える。 | milestone, manual | 0d | 2011-11-24 | 2011-11-24 |  |  | start no earlier than 2011-11-24 |
| 2 | 2 | 前提1 ：主干渉計の光学パラメータや配置が定まる（MIFなど） | milestone, manual | 30d | 2011-11-24 | 2012-01-04 |  |  |  |
| 3 | 3 | 前提2: Viewportのすべての配置が定まる。（VACなど） | milestone, manual | 30d | 2011-11-24 | 2012-01-04 |  |  |  |
| 4 | 4 | 前提3: そのほか、懸架系の脚など、制約条件が定まる。（VISなど） | milestone | 30d | 2011-11-24 | 2012-01-04 |  | 0d |  |
| 6 | 5 | **Stray Light Control 1** |  | 844d | 2012-01-05 | 2015-03-31 |  | 0d |  |
| 7 | 5.1 | **配置の決定** |  | 178d | 2012-01-05 | 2012-09-10 |  | 0d |  |
| 8 | 5.1.1 | 光線追跡 |  | 80d | 2012-01-05 | 2012-04-25 | 2, 3, 4 | 0d |  |
| 9 | 5.1.2 | 全てのバッフルの幾何学的な形状設計とそのZemax上での配置・確認 |  | 70d | 2012-04-26 | 2012-08-01 | 8 | 0d |  |
| 10 | 5.1.3 | 調整予備期間、確定 |  | 28d | 2012-08-02 | 2012-09-10 | 9 | 0d |  |
| 11 | 5.2 | **バッフルのインストール** |  | 666d | 2012-09-11 | 2015-03-31 |  | 0d |  |
| 12 | 5.2.1 | バッフルおよび支持系の図面作成 |  | 180d | 2012-09-11 | 2013-05-20 | 10 | 0d |  |
| 13 | 5.2.2 | 仕様書作成 |  | 70d | 2013-05-21 | 2013-08-26 | 12 | 0d |  |
| 14 | 5.2.3 | 調達作業 |  | 155d | 2013-08-27 | 2014-03-31 | 13 | 0d |  |
| 15 | 5.2.4 | インストール作業 |  | 261d | 2014-04-01 | 2015-03-31 | 14 | 0d |  |
| 17 | 6 | **Stray Light Control 2** |  | 1d? | 2011-11-24 | 2011-11-24 |  | 0d |  |
| 18 | 6.1 | 主干渉計光学系のBRDFの推計 | manual | 1d? | 2011-11-24 | 2011-11-24 |  |  |  |
| 20 | 7 | **Beam Reducing Telescopes** |  | 844d | 2012-01-05 | 2015-03-31 |  | 0d |  |
| 21 | 7.1 | **配置の決定** |  | 178d | 2012-01-05 | 2012-09-10 |  | 0d |  |
| 22 | 7.1.1 | 光線追跡 |  | 80d | 2012-01-05 | 2012-04-25 | 2, 3, 4 | 0d |  |
| 23 | 7.1.2 | Telescope光学系をZemax上に配置 |  | 70d | 2012-04-26 | 2012-08-01 | 22 | 0d |  |
| 24 | 7.1.3 | 調整予備期間、確定 |  | 28d | 2012-08-02 | 2012-09-10 | 23 | 0d |  |
| 25 | 7.2 | **インストレーション** |  | 666d | 2012-09-11 | 2015-03-31 |  | 0d |  |
| 26 | 7.2.1 | 図面作成 |  | 180d | 2012-09-11 | 2013-05-20 | 24 | 0d |  |
| 27 | 7.2.2 | 仕様書作成 |  | 70d | 2013-05-21 | 2013-08-26 | 26 | 0d |  |
| 28 | 7.2.3 | 調達作業 |  | 155d | 2013-08-27 | 2014-03-31 | 27 | 0d |  |
| 29 | 7.2.4 | インストール作業 |  | 261d | 2014-04-01 | 2015-03-31 | 28 | 0d |  |

Notes:
- 1: 冷却懸架系は、bLCGTへの移行時にインストールされ、そのときバッフルなども移動できると仮定する。
- 2: サブグループ間のインタラクションで決まるので書きづらい。。
- 3: サブグループ間のインタラクションで決まるので書きづらい。。 / つまりさらに前提として、リストアップ作業もおわっていなければならない。
- 4: サブグループ間のインタラクションから決まってくるので書きづらい。。
- 6: 大きく分けて2つのパートにわかれる。1つは、干渉計のすべての光軸を迷光もふくめて追跡し、そこに適切なバッフルを置くこと。 / もう1つは、バッフルの設計、調達、インストールである。
- 9: バッフルの幾何学的な形状もいっしょに考えなければならない。図面はあとでだす。iLCGTで迷光はほっておく、という手もあるが、一部の迷光はパワーが大きいと、懸架系のワイヤーやらをかすっただけで焼き切れる恐れもあるので、考慮しておかねばならない。
- 10: 上ではああいったが、行きつ戻りつは結局発生するはずで、そのために1か月を割いておく。
- 15: 2014.3月末の穴掘り終了が本当に穴掘りだけを意味するのであれば、この辺はもう少し細かく決める必要があろう。
- 17: ちょっと、まだ、不明。

| ID | WBS | Task | Type | Duration | Start | Finish | Predecessors | Total slack | Free slack |
| --- | --- | --- | --- | --- | --- | --- | --- | --- | --- |
| 31 | 8 | **Optical Levers** |  | 844d | 2012-01-05 | 2015-03-31 |  | 0d |  |
| 32 | 8.1 | **配置の決定** |  | 178d | 2012-01-05 | 2012-09-10 |  | 0d |  |
| 33 | 8.1.1 | 光線追跡 |  | 80d | 2012-01-05 | 2012-04-25 | 2, 3, 4 | 0d |  |
| 34 | 8.1.2 | Optical LeverをZemax上に配置 |  | 70d | 2012-04-26 | 2012-08-01 | 33 | 0d |  |
| 35 | 8.1.3 | 調整予備期間、確定 |  | 28d | 2012-08-02 | 2012-09-10 | 34 | 0d |  |
| 36 | 8.2 | **インストレーション** |  | 666d | 2012-09-11 | 2015-03-31 |  | 0d |  |
| 37 | 8.2.1 | 図面作成 |  | 180d | 2012-09-11 | 2013-05-20 | 35 | 0d |  |
| 38 | 8.2.2 | 仕様書作成 |  | 70d | 2013-05-21 | 2013-08-26 | 37 | 0d |  |
| 39 | 8.2.3 | 調達作業 |  | 155d | 2013-08-27 | 2014-03-31 | 38 | 0d |  |
| 40 | 8.2.4 | インストール作業 |  | 261d | 2014-04-01 | 2015-03-31 | 39 | 0d |  |
| 42 | 9 | **Stray Light Control 3** |  | 1d? | 2011-11-24 | 2011-11-24 |  | 0d |  |
| 43 | 9.1 | iLCGTではあまり気にしない？ | manual | 1d? | 2011-11-24 | 2011-11-24 |  |  |  |
| 44 | 9.2 | Dark port PDの選定など | manual | 1d? | 2011-11-24 | 2011-11-24 |  |  |  |
| 45 | 9.3 | Output Faradayなど | manual | 1d? | 2011-11-24 | 2011-11-24 |  |  |  |
| 47 | 10 | **Auxiliary Locking (Green Laser)** |  | 666d? | 2012-09-10 | 2015-03-31 |  | 0d |  |
| 48 | 10.1 | **配置の決定** |  | 80d | 2012-09-10 | 2012-12-31 |  | 586d |  |
| 49 | 10.1.1 | BRTの決定時に自動的に決まることになっている。基本的にはbeamの小さくなるミラーのところから入射するつもりなのでBRTいらないのかもしれないが、、、 | milestone | 0d | 2012-09-10 | 2012-09-10 | 24 | 586d | 0d |
| 50 | 10.1.2 | むしろ、センタールーム近辺での真空槽外の光学配置が重要。 |  | 80d | 2012-09-11 | 2012-12-31 | 49 | 586d |  |
| 51 | 10.2 | **インストレーション** |  | 261d? | 2014-04-01 | 2015-03-31 |  | 0d |  |
| 52 | 10.2.1 | たぶん、消耗品だけでなんとかなりそうだけど。。 | manual | 1d? | 2014-04-01 | 2014-04-01 |  |  |  |
| 53 | 10.2.2 | インストール作業 | manual | 261d | 2014-04-01 | 2015-03-31 |  |  |  |
| 55 | 11 | **Video Monitors (CCD cameras or equiv)** |  | 80d? | 2012-01-05 | 2012-04-25 |  | 0d |  |
| 56 | 11.1 | **配置の決定** |  | 80d? | 2012-01-05 | 2012-04-25 |  | 0d |  |
| 57 | 11.1.1 | 光線追跡 |  | 80d | 2012-01-05 | 2012-04-25 | 2, 3, 4 | 764d |  |
| 58 | 11.1.2 | 真空槽の外、または内部におくべきもののリストアップをしっかりしておくこと。 | manual | 1d? | 2012-01-05 | 2012-01-05 |  |  |  |

Notes:
- 42: 信号用photodiodeの散乱光対策などである。もしかしたら、Output Faradayとともに考えるべきことかもしれないが、とりあえずiLCGTでは無しか？

| ID | WBS | Task | Type | Duration | Start | Finish | Predecessors | Total slack | Free slack |
| --- | --- | --- | --- | --- | --- | --- | --- | --- | --- |
| 59 | 12 | **インストレーション** |  | 261d | 2014-04-01 | 2015-03-31 |  | 0d |  |
| 60 | 12.1 | インストール作業 | manual | 261d | 2014-04-01 | 2015-03-31 |  |  |  |
| 62 | 13 | **Viewports (Room Temp)** |  | 844d | 2012-01-05 | 2015-03-31 |  | 0d |  |
| 63 | 13.1 | **配置の決定** |  | 80d | 2012-01-05 | 2012-04-25 |  | 764d |  |
| 64 | 13.1.1 | Zemaxへ反映 |  | 80d | 2012-01-05 | 2012-04-25 | 3 | 764d |  |
| 65 | 13.2 | **インストレーション** |  | 844d | 2012-01-05 | 2015-03-31 |  | 0d |  |
| 66 | 13.2.1 | 図面作成 |  | 180d | 2012-01-05 | 2012-09-12 | 3 | 439d | 0d |
| 67 | 13.2.2 | 仕様書作成 |  | 70d | 2012-09-13 | 2012-12-19 | 66 | 439d | 0d |
| 68 | 13.2.3 | 調達作業 |  | 155d | 2012-12-20 | 2013-07-24 | 67 | 439d |  |
| 69 | 13.2.4 | インストール作業 | manual | 261d | 2014-04-01 | 2015-03-31 |  |  |  |
| 71 | 14 | Initial Alignment | manual | 1d? | 2011-11-24 | 2011-11-24 |  |  |  |
| 72 | 15 | Beam Profiler | manual | 1d? | 2011-11-24 | 2011-11-24 |  |  |  |
| 73 | 16 | Automatic Targets | manual | 1d? | 2011-11-24 | 2011-11-24 |  |  |  |

Notes:
- 71: MIFが主導的にやるとのこと
